Schedule from MS Project, 2010-02-09 to 2011-03-29.

## Calendars

- Standard: Mon-Fri 08:00-12:00, 13:00-17:00; Sat-Sun off.

## Schedule

| ID | WBS | Task | Type | Duration | Start | Finish | Predecessors | Total slack | Free slack | Constraint |
| --- | --- | --- | --- | --- | --- | --- | --- | --- | --- | --- |
| 1 | 1 | **ETS code developments** |  | 172d | 2010-03-29 | 2010-11-23 |  | 90d |  |  |
| 2 | 19.0 | ETS: extend code for varying rho_tor_max |  | 60d | 2010-09-01 | 2010-11-23 |  | 0d |  | start no earlier than 2010-09-01 |
| 3 | 20.0 | ETS running for a fixed but varying boundary shot | milestone | 0d | 2010-11-23 | 2010-11-23 | 2, 22 | 0d |  |  |
| 4 | 1.3 | Impurities |  | 90d | 2010-03-29 | 2010-07-30 |  | 112d | 0d | finish no earlier than 2010-07-30 |
| 5 | 1.4 | V&V |  | 30d | 2010-08-02 | 2010-09-10 | 4 | 142d |  |  |
| 6 | 1.5 | AMNS: delivery of working version | milestone | 0d | 2010-08-31 | 2010-08-31 |  | 91d | 0d | start no earlier than 2010-08-31 |
| 7 | 1.6 | Impurities + AMNS |  | 30d | 2010-08-31 | 2010-10-11 | 4, 6 | 91d | 0d |  |
| 8 | 1.7 | V&V |  | 30d | 2010-10-12 | 2010-11-22 | 7 | 91d |  |  |
| 9 | 1.8 | Developments of solvers to address conservation problems |  | 60d | 2010-07-15 | 2010-10-06 |  | 94d | 0d | start no earlier than 2010-07-15 |
| 10 | 1.9 | V&V |  | 30d | 2010-10-07 | 2010-11-17 | 9 | 94d |  |  |
| 11 | 1.10 | Improve reliability of HELENA |  | 30d | 2010-07-05 | 2010-08-13 |  | 132d | 0d | finish no earlier than 2010-08-13 |
| 12 | 1.11 | Dummy NBI, ICRH and ECRH routines |  | 5d | 2010-08-09 | 2010-08-13 |  | 132d | 0d | finish no earlier than 2010-08-13 |
| 13 | 1.12 | Test workflows starting from JET equilibria |  | 30d | 2010-08-16 | 2010-09-24 | 11, 12 | 132d |  |  |
| 14 | 1.13 | Test workflows starting from AUG equilibria |  | 30d | 2010-08-16 | 2010-09-24 | 11, 12 | 132d |  |  |
| 15 | 1.14 | Test neoclassical modules |  | 30d | 2010-08-16 | 2010-09-24 | 11 | 132d |  |  |
| 16 | 2 | **ETS SS** |  | 201d | 2010-02-15 | 2010-11-22 |  | 0d |  |  |
| 17 | 1.0 | EDRG: equil import | milestone | 0d | 2010-02-15 | 2010-02-15 |  | 0d |  | must start on 2010-02-15 |
| 18 | 2.0 | IMP12: EFIT to HELENA | milestone | 0d | 2010-02-15 | 2010-02-15 | 17 | 262d | 1d |  |
| 19 | 3.0 | EDRG: coresource import | milestone | 0d | 2010-08-31 | 2010-08-31 |  | 31d | 0d | start no earlier than 2010-08-31 |
| 20 | 2.4 | IMP4: Transport modules | milestone | 0d | 2010-08-31 | 2010-08-31 | 19 | 31d | 0d |  |
| 21 | 4.0 | ETS implementation for SS |  | 30d | 2010-08-31 | 2010-10-11 | 17, 20 | 31d | 0d |  |
| 22 | 5.0 | ETS running for a steady state shot (F) | milestone | 0d | 2010-10-11 | 2010-10-11 | 21 | 31d | 0d |  |
| 23 | 6.0 | EDRG: coreprof import | milestone | 0d | 2010-08-31 | 2010-08-31 |  | 121d | 30d | start no earlier than 2010-08-31 |
| 24 | 7.0 | ETS V&V |  | 30d | 2010-10-12 | 2010-11-22 | 22, 23 | 91d | 0d |  |
| 25 | 8.0 | ETS V&V MS | milestone | 0d | 2010-11-22 | 2010-11-22 | 24 | 91d |  |  |

| ID | WBS | Task | Type | Duration | Start | Finish | Predecessors | Total slack | Free slack | Constraint |
| --- | --- | --- | --- | --- | --- | --- | --- | --- | --- | --- |
| 26 | 3 | **Neutrals** |  | 30d | 2010-02-09 | 2010-03-22 |  | 266d |  |  |
| 27 | 3.1 | V&V |  | 30d | 2010-02-09 | 2010-03-22 |  | 266d |  |  |
| 28 | 4 | **Pellets** |  | 120d | 2010-07-15 | 2010-12-29 |  | 64d |  |  |
| 29 | 4.1 | Develop |  | 90d | 2010-07-15 | 2010-11-17 |  | 64d | 0d | start no earlier than 2010-07-15 |
| 30 | 4.2 | V&V |  | 30d | 2010-11-18 | 2010-12-29 | 29 | 64d |  |  |
| 31 | 5 | **ETS + Sawteeth** |  | 205d | 2010-02-09 | 2010-11-22 |  | 91d |  |  |
| 32 | 9.0 | IMP12: sawteeth model | milestone | 0d | 2010-02-09 | 2010-02-09 |  | 236d | 0d |  |
| 33 | 10.0 | ETS development |  | 30d | 2010-02-09 | 2010-03-22 | 32 | 236d | 145d |  |
| 34 | 11.0 | ETS running for a steady state shot with sawteeth (F) | milestone | 0d | 2010-10-11 | 2010-10-11 | 22, 33 | 91d | 0d |  |
| 35 | 12.0 | ETS + Sawteeth V&V |  | 30d | 2010-10-12 | 2010-11-22 | 34 | 91d | 0d |  |
| 36 | 13.0 | ETS + Sawteeth V&V MS | milestone | 0d | 2010-11-22 | 2010-11-22 | 35 | 91d |  |  |
| 37 | 6 | **ETS + NBI** |  | 60d | 2010-08-31 | 2010-11-22 |  | 91d |  |  |
| 38 | 14.0 | IMP5: NBI module | milestone | 0d | 2010-08-31 | 2010-08-31 |  | 91d | 0d | start no earlier than 2010-08-31 |
| 39 | 15.0 | ETS Development |  | 30d | 2010-08-31 | 2010-10-11 | 38 | 91d | 0d |  |
| 40 | 16.0 | ETS running for a steady state shot with ITM sources (F) | milestone | 0d | 2010-10-11 | 2010-10-11 | 39 | 91d | 0d |  |
| 41 | 17.0 | ETS + NBI V&V |  | 30d | 2010-10-12 | 2010-11-22 | 40 | 91d | 0d |  |
| 42 | 18.0 | ETS + NBI V&V MS | milestone | 0d | 2010-11-22 | 2010-11-22 | 41 | 91d |  |  |
| 43 | 7 | **ETS + ICRH** |  | 60d | 2010-08-31 | 2010-11-22 |  | 91d |  |  |
| 44 | 14.0 | IMP5: ICRH module | milestone | 0d | 2010-08-31 | 2010-08-31 |  | 91d | 0d | start no earlier than 2010-08-31 |
| 45 | 15.0 | ETS Development |  | 30d | 2010-08-31 | 2010-10-11 | 44 | 91d | 0d |  |
| 46 | 16.0 | ETS running for a steady state shot with ITM sources (F) | milestone | 0d | 2010-10-11 | 2010-10-11 | 45 | 91d | 0d |  |
| 47 | 17.0 | ETS + ICRH V&V |  | 30d | 2010-10-12 | 2010-11-22 | 46 | 91d | 0d |  |
| 48 | 18.0 | ETS + ICRH V&V MS | milestone | 0d | 2010-11-22 | 2010-11-22 | 47 | 91d |  |  |
| 49 | 8 | **ETS + ECRH** |  | 60d | 2010-08-31 | 2010-11-22 |  | 91d |  |  |
| 50 | 14.0 | IMP5: ECRH module | milestone | 0d | 2010-08-31 | 2010-08-31 |  | 91d | 0d | start no earlier than 2010-08-31 |
| 51 | 15.0 | ETS Development |  | 30d | 2010-08-31 | 2010-10-11 | 50 | 91d | 0d |  |
| 52 | 16.0 | ETS running for a steady state shot with ITM sources (F) | milestone | 0d | 2010-10-11 | 2010-10-11 | 51 | 91d | 0d |  |
| 53 | 17.0 | ETS + ECRH V&V |  | 30d | 2010-10-12 | 2010-11-22 | 52 | 91d | 0d |  |
| 54 | 18.0 | ETS + ICRH V&V MS | milestone | 0d | 2010-11-22 | 2010-11-22 | 53 | 91d |  |  |

| ID | WBS | Task | Type | Duration | Start | Finish | Predecessors | Total slack | Free slack | Constraint |
| --- | --- | --- | --- | --- | --- | --- | --- | --- | --- | --- |
| 55 | 9 | **ETS+Kepler** |  | 296d | 2010-02-09 | 2011-03-29 |  | 0d |  |  |
| 56 | 21.0 | Kepler with debugging | milestone | 0d | 2010-02-09 | 2010-02-09 |  | 261d | 0d |  |
| 57 | 22.0 | HELENA actor | milestone | 0d | 2010-02-09 | 2010-02-09 | 56 | 266d | 5d |  |
| 58 | 23.0 | ETS actor |  | 5d | 2010-02-09 | 2010-02-15 | 56 | 261d | 0d |  |
| 59 | 24.0 | ETS workflow in Kepler |  | 10d | 2010-02-16 | 2010-03-01 | 18, 56, 57, 58 | 261d | 130d |  |
| 60 | 25.0 | ETS workflow development (core source from EXP) |  | 10d | 2010-08-31 | 2010-09-13 | 19, 59, 20 | 131d | 0d |  |
| 61 | 26.0 | ETS running for a steady state shot (K) | milestone | 0d | 2010-09-13 | 2010-09-13 | 60 | 131d | 0d |  |
| 62 | 27.0 | ETS V&V (K) |  | 10d | 2010-09-14 | 2010-09-27 | 61 | 131d | 0d |  |
| 63 | 28.0 | ETS V&V (K) MS | milestone | 0d | 2010-09-27 | 2010-09-27 | 62 | 131d |  |  |
| 64 | 9.9 | **Sawteeth** |  | 20d | 2010-08-31 | 2010-09-27 |  | 131d |  |  |
| 65 | 29.0 | IMP12: Sawtooth actor | milestone | 0d | 2010-08-31 | 2010-08-31 | 32, 56 | 140d | 0d | start no earlier than 2010-08-31 |
| 66 | 30.0 | ETS workflow development |  | 1d | 2010-08-31 | 2010-08-31 | 65 | 140d | 9d |  |
| 67 | 31.0 | ETS running for a steady state shot with sawteeth (K) | milestone | 0d | 2010-09-13 | 2010-09-13 | 61, 66 | 131d | 0d |  |
| 68 | 32.0 | ETS + Sawteeth V&V (K) |  | 10d | 2010-09-14 | 2010-09-27 | 67 | 131d | 0d |  |
| 69 | 33.0 | ETS + Sawteeth V&V (K) MS | milestone | 0d | 2010-09-27 | 2010-09-27 | 68 | 131d |  |  |
| 70 | 9.10 | **NBI** |  | 35d | 2010-08-31 | 2010-10-18 |  | 116d |  |  |
| 71 | 34.0 | IMP5: NBI actor | milestone | 0d | 2010-08-31 | 2010-08-31 | 38, 56 | 116d | 0d |  |
| 72 | 35.0 | ETS workflow development |  | 5d | 2010-08-31 | 2010-09-06 | 71 | 116d | 0d |  |
| 73 | 36.0 | ETS running for a steady state shot with ITM sources (K) | milestone | 0d | 2010-09-06 | 2010-09-06 | 72 | 116d | 0d |  |
| 74 | 9.10.4 | V&V |  | 30d | 2010-09-07 | 2010-10-18 | 73 | 116d |  |  |
| 75 | 9.11 | **ICRH** |  | 35d | 2010-08-31 | 2010-10-18 |  | 116d |  |  |
| 76 | 34.0 | IMP5: ICRH actor | milestone | 0d | 2010-08-31 | 2010-08-31 | 44 | 116d | 0d |  |
| 77 | 35.0 | ETS workflow development |  | 5d | 2010-08-31 | 2010-09-06 | 76 | 116d | 0d |  |
| 78 | 36.0 | ETS running for a steady state shot with ITM sources (K) | milestone | 0d | 2010-09-06 | 2010-09-06 | 77 | 116d | 0d |  |
| 79 | 9.11.4 | V&V |  | 30d | 2010-09-07 | 2010-10-18 | 78 | 116d |  |  |

| ID | WBS | Task | Type | Duration | Start | Finish | Predecessors | Total slack | Free slack | Constraint |
| --- | --- | --- | --- | --- | --- | --- | --- | --- | --- | --- |
| 80 | 9.12 | **ECRH** |  | 35d | 2010-08-31 | 2010-10-18 |  | 116d |  |  |
| 81 | 34.0 | IMP5: ECRH actor | milestone | 0d | 2010-08-31 | 2010-08-31 | 50 | 116d | 0d |  |
| 82 | 35.0 | ETS workflow development |  | 5d | 2010-08-31 | 2010-09-06 | 81 | 116d | 0d |  |
| 83 | 36.0 | ETS running for a steady state shot with ITM sources (K) | milestone | 0d | 2010-09-06 | 2010-09-06 | 82 | 116d | 0d |  |
| 84 | 9.12.4 | V&V |  | 30d | 2010-09-07 | 2010-10-18 | 83 | 116d |  |  |
| 85 | 9.13 | **Free Boundary** |  | 128d | 2010-10-01 | 2011-03-29 |  | 0d |  |  |
| 86 | 37.0 | IMP12: free boundary equilibrium code | milestone | 0d | 2010-10-01 | 2010-10-01 |  | 38d |  | start no earlier than 2010-10-01 |
| 87 | 38.0 | ETS: Implementation of free boundary equilibrium |  | 60d | 2010-11-24 | 2011-02-15 | 86, 3 | 0d |  |  |
| 88 | 39.0 | ETS running for a free boundary shot | milestone | 0d | 2011-02-15 | 2011-02-15 | 87 | 0d |  |  |
| 89 | 9.13.4 | V&V |  | 30d | 2011-02-16 | 2011-03-29 | 88 | 0d |  |  |
